# SUBPROYECTO A3

Schedule from Primavera P6, 2023-05-10 to 2023-11-21, data date 2023-05-10.

## Calendars

- 1T - 7x0 - 8 hr: Mon-Sun 08:00-16:00.

## Schedule

| ID | WBS | Activity | Type | Duration | Start | Finish | Predecessors | Total float | Free float |
| --- | --- | --- | --- | --- | --- | --- | --- | --- | --- |
|  | 0 | **HITOS** |  |  | 2023-05-10 | 2023-11-19 |  |  |  |
| A1000 |  | KICK OFF MEETING | milestone | 0d | 2023-05-10 | 2023-05-10 |  | 0d |  |
| A1010 |  | INICIO DEL SERVICIO | milestone | 0d | 2023-05-26 | 2023-05-26 | A1000 FS+16d | 0d |  |
| A1015 |  | INICIO DE EXCAVACIÓN | milestone | 0d | 2023-05-31 | 2023-05-31 | A1010 FS+5d, A1070 SS+3d | 0d |  |
| A1016 |  | INICIO DE RELLENO DE DIQUE | milestone | 0d | 2023-06-22 | 2023-06-22 | A1015 SS+22d, A1340 | 0d |  |
| A1020 |  | FIN DEL SERVICIO | milestone | 0d | 2023-11-19 | 2023-11-19 | A1200, A2220, A2490, A1760, A1780, A1070, A2760, A2700, A1050, A2210, A4020, A3850, A3790, A3780, A3740, A3730, A3640, A3630, A3580, A3560, A3550, A3530, A3470, A3450, A3400, A3260, A3160, A3140, A3130, A3080, A2930, A2880, A4130, A4150, A4160 | 0d |  |
|  | 1 | **DEFENSAS RIBEREÑAS** |  |  | 2023-05-26 | 2023-11-21 |  |  |  |
|  | 1 | **OBRAS PRELIMINARES** |  |  | 2023-05-28 | 2023-11-17 |  |  |  |
| A1030 |  | CARTEL DE IDENTIFICACIÓN OBRA 4.80 x 3.60 m. |  | 2d | 2023-05-28 | 2023-05-29 | A1060 SS+2d | 2d |  |
| A1040 |  | INSTALACIONES PROVISIONALES PARA LA OBRA |  | 169d | 2023-06-01 | 2023-11-16 | A1100 SS+1d, A1030 | 0d |  |
| A1050 |  | MANTENIMIENTO DE TRÁNSITO Y SEGURIDAD VIAL |  | 154d | 2023-06-17 | 2023-11-17 | A1100 | 2d |  |
|  | 2 | **TRABAJOS PRELIMINARES** |  |  | 2023-05-26 | 2023-11-21 |  |  |  |
| A1060 |  | MOVILIZACION DE EQUIPOS |  | 31d | 2023-05-26 | 2023-06-25 | A1010 | 0d |  |
| A1070 |  | TOPOGRAFÍA Y GEOREFERENCIACIÓN |  | 174d | 2023-05-28 | 2023-11-17 | A1060 SS+2d | 0d |  |
| A1080 |  | DESMOVILIZACION DE EQUIPOS |  | 23d | 2023-10-30 | 2023-11-21 | A1020 FF+2d | 0d |  |
|  | 3 | **MEJORAMIENTO DE VÍAS EXISTENTES** |  |  | 2023-05-31 | 2023-07-30 |  |  |  |
|  | 1 | **MOVIMIENTO DE TIERRAS** |  |  | 2023-05-31 | 2023-06-16 |  |  |  |
| A1090 |  | ROCE Y LIMPIEZA DE MALEZA |  | 17d | 2023-05-31 | 2023-06-16 | A1015 | 0d |  |
| A1100 |  | MEJORAMIENTO DE VIAS EXISTENTES |  | 17d | 2023-05-31 | 2023-06-16 | A1090 SS | 0d |  |
|  | 2 | **REPOSICIÓN DE ESTRUCTURAS** |  |  | 2023-06-20 | 2023-07-24 |  |  |  |
| A1150 |  | DEMOLICIÓN DE ESTRUCTURAS EXISTENTES |  | 2d | 2023-06-20 | 2023-06-21 | A1070 SS+23d | 112d | 0d |
| A1160 |  | REPOSICIÓN DE PASE DE AGUA TUBO HDPE Ø=18" |  | 2d | 2023-06-23 | 2023-06-24 | A1150 SS+3d | 112d | 0d |
| A1170 |  | REPOSICIÓN DE PASE DE AGUA TUBO HDPE Ø=36" |  | 2d | 2023-06-23 | 2023-06-24 | A1160 SS | 112d | 0d |
| A1180 |  | SUMINISTRO Y MONTAJE DE PANELES DE C°A° 1.6mx1.0mx0.20m EN PASE DE AGUA |  | 30d | 2023-06-25 | 2023-07-24 | A1170 SS+2d | 112d | 0d |
| A1190 |  | SUMINISTRO Y MONTAJE DE PANELES DE C°A° 2.20mx1.0mx0.20m EN PASE DE AGUA |  | 30d | 2023-06-25 | 2023-07-24 | A1180 SS | 112d | 0d |

| ID | WBS | Activity | Duration | Start | Finish | Predecessors | Total float | Free float | Filtro |
| --- | --- | --- | --- | --- | --- | --- | --- | --- | --- |
|  | 4 | **CABEZAL DE ENTRADA Y SALIDA** |  | 2023-07-25 | 2023-07-30 |  |  |  |  |
| A1210 |  | ENCOFRADO Y DESENCOFRADO RECTO | 3d | 2023-07-25 | 2023-07-27 | A1190 | 112d | 0d |  |
| A1200 |  | CONCRETOS | 3d | 2023-07-28 | 2023-07-30 | A1210 | 112d |  |  |
|  | 4 | **DESCOLMATACIÓN DE CAUCE Y OBRAS AUXILIARES** |  | 2023-06-02 | 2023-11-19 |  |  |  |  |
|  | 1 | **DESBROCE Y DESCOLMATACIÓN** |  | 2023-06-02 | 2023-08-26 |  |  |  |  |
| A1220 |  | DESBROCE Y LIMPIEZA EN ZONA NO BOSCOSA | 76d | 2023-06-02 | 2023-08-16 | A1070 SS+4d, A1015, A1040 SS+1d | 0d |  | Excavación |
| A1230 |  | DESCOLMATACIÓN DE CAUCE NATURAL DEL RÍO LACRAMARCA - DIQUE A3-D-01 | 10d | 2023-06-02 | 2023-06-11 | A1220 SS | 0d |  | Excavación |
| A1880 |  | DESCOLMATACIÓN DE CAUCE NATURAL DEL RÍO LACRAMARCA - DIQUE A3-I-01 | 32d | 2023-06-02 | 2023-07-03 | A1230 SS | 0d |  | Excavación |
| A1870 |  | DESCOLMATACIÓN DE CAUCE NATURAL DEL RÍO LACRAMARCA - DIQUE A3-D-02 | 53d | 2023-06-12 | 2023-08-03 | A1230 | 39d |  | Excavación |
| A1890 |  | DESCOLMATACIÓN DE CAUCE NATURAL DEL RÍO LACRAMARCA - DIQUE A3-I-02 | 20d | 2023-07-04 | 2023-07-23 | A1880 | 0d |  | Excavación |
| A1900 |  | DESCOLMATACIÓN DE CAUCE NATURAL DEL RÍO LACRAMARCA - DIQUE A3-I-03 | 34d | 2023-07-24 | 2023-08-26 | A1890 | 4d |  | Excavación |
|  | 2 | **DESVIO DEL CAUCE** |  | 2023-06-03 | 2023-11-19 |  |  |  |  |
|  | 1 | **A3-D-01** |  | 2023-07-06 | 2023-07-15 |  |  |  |  |
| A1240 |  | CONFORMACIÓN DE DESVIO EN CAUCE DE RÍO - DIQUE A3-D-01 | 5d | 2023-07-06 | 2023-07-10 | A1230 SS, A1330 FF+2d | 0d |  | Excavación |
| A1250 |  | RELLENO NO ESTRUCTURAL CON MATERIAL PROPIO - DIQUE A3-D-01 | 7d | 2023-07-09 | 2023-07-15 | A1330 | 92d | 17d | Relleno |
|  | 2 | **A3-D-02** |  | 2023-07-23 | 2023-11-11 |  |  |  |  |
| A1790 |  | CONFORMACIÓN DE DESVIO EN CAUCE DE RÍO - DIQUE A3-D-02 - TRAMO 1 | 5d | 2023-07-23 | 2023-07-27 | A1870 SS+2d, A1510 FF+2d | 0d |  | Excavación |
| A1800 |  | RELLENO NO ESTRUCTURAL CON MATERIAL PROPIO - DIQUE A3-D-02 - TRAMO 1 | 7d | 2023-08-02 | 2023-08-08 | A1420, A1250 | 75d | 17d | Relleno |
| A2630 |  | CONFORMACIÓN DE DESVIO EN CAUCE DE RÍO - DIQUE A3-D-02 - TRAMO 2 | 5d | 2023-08-16 | 2023-08-20 | A1600 FF+2d | 0d |  | Excavación |
| A2640 |  | RELLENO NO ESTRUCTURAL CON MATERIAL PROPIO - DIQUE A3-D-02 - TRAMO 2 | 7d | 2023-08-26 | 2023-09-01 | A1980, A1800 | 58d | 17d | Relleno |
| A2650 |  | CONFORMACIÓN DE DESVIO EN CAUCE DE RÍO - DIQUE A3-D-02 - TRAMO 3 | 5d | 2023-09-08 | 2023-09-12 | A1690 FF+2d | 0d |  | Excavación |
| A2660 |  | RELLENO NO ESTRUCTURAL CON MATERIAL PROPIO - DIQUE A3-D-02 - TRAMO 3 | 7d | 2023-09-19 | 2023-09-25 | A2070, A2640 | 41d | 17d | Relleno |
| A2670 |  | CONFORMACIÓN DE DESVIO EN CAUCE DE RÍO - DIQUE A3-D-02 - TRAMO 4 | 5d | 2023-09-25 | 2023-09-29 | A2340 FF+2d | 0d |  | Excavación |
| A2680 |  | RELLENO NO ESTRUCTURAL CON MATERIAL PROPIO - DIQUE A3-D-02 - TRAMO 4 | 7d | 2023-10-13 | 2023-10-19 | A2160, A2660 | 24d | 16d | Relleno |
| A2690 |  | CONFORMACIÓN DE DESVIO EN CAUCE DE RÍO - DIQUE A3-D-02 - TRAMO 5 | 5d | 2023-10-18 | 2023-10-22 | A2430 FF+2d | 0d |  | Excavación |
| A2700 |  | RELLENO NO ESTRUCTURAL CON MATERIAL PROPIO - DIQUE A3-D-02 - TRAMO 5 | 7d | 2023-11-05 | 2023-11-11 | A2250, A2680 | 8d |  | Relleno |

| ID | WBS | Activity | Duration | Start | Finish | Predecessors | Total float | Free float | Filtro |
| --- | --- | --- | --- | --- | --- | --- | --- | --- | --- |
|  | 3 | **A3-I-01** |  | 2023-06-03 | 2023-08-01 |  |  |  |  |
| A1810 |  | CONFORMACIÓN DE DESVIO EN CAUCE DE RÍO - DIQUE A3-I-01 | 5d | 2023-06-03 | 2023-06-07 | A1880 SS+1d | 0d |  | Excavación |
| A1820 |  | RELLENO NO ESTRUCTURAL CON MATERIAL PROPIO - DIQUE A3-I-01 | 7d | 2023-07-26 | 2023-08-01 | A1510 | 75d | 17d | Relleno |
|  | 4 | **A3-I-02** |  | 2023-07-06 | 2023-08-25 |  |  |  |  |
| A1830 |  | CONFORMACIÓN DE DESVIO EN CAUCE DE RÍO - DIQUE A3-I-02 | 5d | 2023-07-06 | 2023-07-10 | A1890 SS+2d, A1330 FF+2d | 0d |  | Excavación |
| A1840 |  | RELLENO NO ESTRUCTURAL CON MATERIAL PROPIO - DIQUE A3-I-02 | 7d | 2023-08-19 | 2023-08-25 | A1600, A1820 | 58d | 16d | Relleno |
|  | 5 | **A3-I-03** |  | 2023-07-30 | 2023-11-19 |  |  |  |  |
| A1850 |  | CONFORMACIÓN DE DESVIO EN CAUCE DE RÍO - DIQUE A3-I-03 - TRAMO 1 | 5d | 2023-07-30 | 2023-08-03 | A1900 SS+2d, A1420 FF+2d | 0d |  | Excavación |
| A2710 |  | CONFORMACIÓN DE DESVIO EN CAUCE DE RÍO - DIQUE A3-I-03 - TRAMO 2 | 5d | 2023-08-23 | 2023-08-27 | A1980 FF+2d | 0d |  | Excavación |
| A1860 |  | RELLENO NO ESTRUCTURAL CON MATERIAL PROPIO - DIQUE A3-I-03 -TRAMO 1 | 7d | 2023-09-11 | 2023-09-17 | A1690, A1840 | 42d | 10d | Relleno |
| A2730 |  | CONFORMACIÓN DE DESVIO EN CAUCE DE RÍO - DIQUE A3-I-03 - TRAMO 3 | 5d | 2023-09-16 | 2023-09-20 | A2070 FF+2d | 0d |  | Excavación |
| A2720 |  | RELLENO NO ESTRUCTURAL CON MATERIAL PROPIO - DIQUE A3-I-03 -TRAMO 2 | 7d | 2023-09-28 | 2023-10-04 | A2340, A1860 | 32d | 16d | Relleno |
| A2750 |  | CONFORMACIÓN DE DESVIO EN CAUCE DE RÍO - DIQUE A3-I-03 - TRAMO 4 | 5d | 2023-10-10 | 2023-10-14 | A2160 FF+2d | 0d |  | Excavación |
| A2740 |  | RELLENO NO ESTRUCTURAL CON MATERIAL PROPIO - DIQUE A3-I-03 -TRAMO 3 | 7d | 2023-10-21 | 2023-10-27 | A2430, A2720 | 16d |  | Relleno |
| A2760 |  | RELLENO NO ESTRUCTURAL CON MATERIAL PROPIO - DIQUE A3-I-03 -TRAMO 4 | 7d | 2023-11-13 | 2023-11-19 | A2520, A2740 | 0d |  | Relleno |
|  | 5 | **DIQUES DE TIERRA COMPACTADA CON ENROCADO** |  | 2023-06-08 | 2023-11-19 |  |  |  |  |
|  | 1 | **DIQUE DE TIERRA COMPACTADA A3-D-01** |  | 2023-06-08 | 2023-07-11 |  |  |  |  |
| A1260 |  | EXCAVACIÓN EN TERRENO NATURAL CON EQUIPO | 10d | 2023-06-08 | 2023-06-17 | A1810 | 0d |  | Excavación |
| A1270 |  | EXCAVACIÓN DE UÑA CON EQUIPO | 9d | 2023-06-09 | 2023-06-17 | A1260 SS+1d | 91d | 24d | Excavación |
| A1280 |  | PERFILADO Y COMPACTACIÓN EN ZONA DE CORTE | 20d | 2023-06-09 | 2023-06-28 | A1260 SS+1d | 0d |  |  |
| A1340 |  | PREPARACIÓN DE FUNDACIÓN DE CUERPO DE DIQUE | 13d | 2023-06-09 | 2023-06-21 | A1280 SS | 0d |  |  |
| A1290 |  | CONFORMACIÓN DE CUERPO DE DIQUE CON MATERIAL PROPIO | 5d | 2023-06-22 | 2023-06-26 | A1016 | 0d |  | Relleno |
| A1310 |  | GEOTEXTIL NO TEJIDO 400 G/M2, INC. COLOCACIÓN | 6d | 2023-06-24 | 2023-06-29 | A1290 SS+2d | 0d |  |  |
| A1320 |  | COLOCACION Y ACOMODO DE ROCA EN UÑA DE DIQUE | 6d | 2023-06-25 | 2023-06-30 | A1310 SS+1d | 0d |  | Roca |
| A1330 |  | COLOCACION Y ACOMODO DE ROCA EN TALUD DE DIQUE | 12d | 2023-06-27 | 2023-07-08 | A1320 SS+2d | 0d |  | Roca |
| A1300 |  | CONFORMACIÓN DE CORONA DE DIQUE CON MATERIAL PROPIO | 6d | 2023-07-06 | 2023-07-11 | A1330 FF+3d | 97d | 18d | Relleno |

| ID | WBS | Activity | Duration | Start | Finish | Predecessors | Total float | Free float | Filtro |
| --- | --- | --- | --- | --- | --- | --- | --- | --- | --- |
|  | 2 | **DIQUE DE TIERRA COMPACTADA A3-D-02** |  | 2023-07-11 | 2023-11-07 |  |  |  |  |
|  | 1 | **TRAMO 1** |  | 2023-07-11 | 2023-08-04 |  |  |  |  |
| A1350 |  | EXCAVACIÓN EN TERRENO NATURAL CON EQUIPO | 9d | 2023-07-11 | 2023-07-19 | A1830 | 0d |  | Excavación |
| A1360 |  | EXCAVACIÓN DE UÑA CON EQUIPO | 11d | 2023-07-12 | 2023-07-22 | A1350 SS+1d, A1270 | 67d | 13d | Excavación |
| A1370 |  | PERFILADO Y COMPACTACIÓN EN ZONA DE CORTE | 12d | 2023-07-12 | 2023-07-23 | A1350 SS+1d | 0d |  |  |
| A1400 |  | GEOTEXTIL NO TEJIDO 400 G/M2, INC. COLOCACIÓN | 13d | 2023-07-14 | 2023-07-26 | A1370 SS+2d | 0d |  |  |
| A1410 |  | COLOCACION Y ACOMODO DE ROCA EN UÑA DE DIQUE | 16d | 2023-07-16 | 2023-07-31 | A1400 SS+2d | 0d |  | Roca |
| A1420 |  | COLOCACION Y ACOMODO DE ROCA EN TALUD DE DIQUE | 15d | 2023-07-18 | 2023-08-01 | A1410 SS+2d | 0d |  | Roca |
| A1430 |  | PREPARACIÓN DE FUNDACIÓN DE CUERPO DE DIQUE | 5d | 2023-07-20 | 2023-07-24 | A1350 | 77d | 0d |  |
| A1380 |  | CONFORMACIÓN DE CUERPO DE DIQUE CON MATERIAL PROPIO | 5d | 2023-07-21 | 2023-07-25 | A1430 SS+1d | 77d | 19d | Relleno |
| A1390 |  | CONFORMACIÓN DE CORONA DE DIQUE CON MATERIAL PROPIO | 6d | 2023-07-30 | 2023-08-04 | A1420 FF+3d, A1300 | 79d | 18d | Relleno |
|  | 2 | **TRAMO 2** |  | 2023-08-04 | 2023-08-28 |  |  |  |  |
| A1910 |  | EXCAVACIÓN EN TERRENO NATURAL CON EQUIPO | 9d | 2023-08-04 | 2023-08-12 | A1850 | 0d |  | Excavación |
| A1920 |  | EXCAVACIÓN DE UÑA CON EQUIPO | 11d | 2023-08-05 | 2023-08-15 | A1910 SS+1d, A1360 | 54d | 13d | Excavación |
| A1930 |  | PERFILADO Y COMPACTACIÓN EN ZONA DE CORTE | 12d | 2023-08-05 | 2023-08-16 | A1910 SS+1d | 0d |  |  |
| A1960 |  | GEOTEXTIL NO TEJIDO 400 G/M2, INC. COLOCACIÓN | 12d | 2023-08-07 | 2023-08-18 | A1930 SS+2d | 0d |  |  |
| A1970 |  | COLOCACION Y ACOMODO DE ROCA EN UÑA DE DIQUE | 16d | 2023-08-09 | 2023-08-24 | A1960 SS+2d | 0d |  | Roca |
| A1980 |  | COLOCACION Y ACOMODO DE ROCA EN TALUD DE DIQUE | 15d | 2023-08-11 | 2023-08-25 | A1970 SS+2d | 0d |  | Roca |
| A1990 |  | PREPARACIÓN DE FUNDACIÓN DE CUERPO DE DIQUE | 5d | 2023-08-13 | 2023-08-17 | A1910 | 58d | 0d |  |
| A1940 |  | CONFORMACIÓN DE CUERPO DE DIQUE CON MATERIAL PROPIO | 5d | 2023-08-14 | 2023-08-18 | A1990 SS+1d, A1380 | 58d | 19d | Relleno |
| A1950 |  | CONFORMACIÓN DE CORONA DE DIQUE CON MATERIAL PROPIO | 6d | 2023-08-23 | 2023-08-28 | A1980 FF+3d, A1390 | 61d | 18d | Relleno |
|  | 3 | **TRAMO 3** |  | 2023-08-28 | 2023-09-21 |  |  |  |  |
| A2000 |  | EXCAVACIÓN EN TERRENO NATURAL CON EQUIPO | 9d | 2023-08-28 | 2023-09-05 | A2710 | 0d |  | Excavación |
| A2010 |  | EXCAVACIÓN DE UÑA CON EQUIPO | 11d | 2023-08-29 | 2023-09-08 | A2000 SS+1d, A1920 | 41d | 13d | Excavación |
| A2020 |  | PERFILADO Y COMPACTACIÓN EN ZONA DE CORTE | 12d | 2023-08-29 | 2023-09-09 | A2000 SS+1d | 0d |  |  |
| A2050 |  | GEOTEXTIL NO TEJIDO 400 G/M2, INC. COLOCACIÓN | 12d | 2023-08-31 | 2023-09-11 | A2020 SS+2d | 0d |  |  |
| A2060 |  | COLOCACION Y ACOMODO DE ROCA EN UÑA DE DIQUE | 16d | 2023-09-02 | 2023-09-17 | A2050 SS+2d | 0d |  | Roca |
| A2070 |  | COLOCACION Y ACOMODO DE ROCA EN TALUD DE DIQUE | 15d | 2023-09-04 | 2023-09-18 | A2060 SS+2d | 0d |  | Roca |
| A2080 |  | PREPARACIÓN DE FUNDACIÓN DE CUERPO DE DIQUE | 5d | 2023-09-06 | 2023-09-10 | A2000 | 39d | 0d |  |
| A2030 |  | CONFORMACIÓN DE CUERPO DE DIQUE CON MATERIAL PROPIO | 5d | 2023-09-07 | 2023-09-11 | A2080 SS+1d, A1940 | 39d | 19d | Relleno |
| A2040 |  | CONFORMACIÓN DE CORONA DE DIQUE CON MATERIAL PROPIO | 6d | 2023-09-16 | 2023-09-21 | A2070 FF+3d, A1950 | 43d | 18d | Relleno |

| ID | WBS | Activity | Duration | Start | Finish | Predecessors | Total float | Free float | Filtro |
| --- | --- | --- | --- | --- | --- | --- | --- | --- | --- |
|  | 4 | **TRAMO 4** |  | 2023-09-21 | 2023-10-15 |  |  |  |  |
| A2090 |  | EXCAVACIÓN EN TERRENO NATURAL CON EQUIPO | 9d | 2023-09-21 | 2023-09-29 | A2730 | 0d |  | Excavación |
| A2100 |  | EXCAVACIÓN DE UÑA CON EQUIPO | 11d | 2023-09-22 | 2023-10-02 | A2090 SS+1d, A2010 | 28d | 13d | Excavación |
| A2110 |  | PERFILADO Y COMPACTACIÓN EN ZONA DE CORTE | 12d | 2023-09-22 | 2023-10-03 | A2090 SS+1d | 0d |  |  |
| A2140 |  | GEOTEXTIL NO TEJIDO 400 G/M2, INC. COLOCACIÓN | 12d | 2023-09-24 | 2023-10-05 | A2110 SS+2d | 0d |  |  |
| A2150 |  | COLOCACION Y ACOMODO DE ROCA EN UÑA DE DIQUE | 16d | 2023-09-26 | 2023-10-11 | A2140 SS+2d | 0d |  | Roca |
| A2160 |  | COLOCACION Y ACOMODO DE ROCA EN TALUD DE DIQUE | 15d | 2023-09-28 | 2023-10-12 | A2150 SS+2d | 0d |  | Roca |
| A2170 |  | PREPARACIÓN DE FUNDACIÓN DE CUERPO DE DIQUE | 5d | 2023-09-30 | 2023-10-04 | A2090 | 20d | 0d |  |
| A2120 |  | CONFORMACIÓN DE CUERPO DE DIQUE CON MATERIAL PROPIO | 5d | 2023-10-01 | 2023-10-05 | A2170 SS+1d, A2030 | 20d | 19d | Relleno |
| A2130 |  | CONFORMACIÓN DE CORONA DE DIQUE CON MATERIAL PROPIO | 6d | 2023-10-10 | 2023-10-15 | A2160 FF+3d, A2040 | 25d | 17d | Relleno |
|  | 5 | **TRAMO 5** |  | 2023-10-15 | 2023-11-07 |  |  |  |  |
| A2180 |  | EXCAVACIÓN EN TERRENO NATURAL CON EQUIPO | 9d | 2023-10-15 | 2023-10-23 | A2750 | 0d |  | Excavación |
| A2190 |  | EXCAVACIÓN DE UÑA CON EQUIPO | 11d | 2023-10-16 | 2023-10-26 | A2180 SS+1d, A2100 | 15d | 0d | Excavación |
| A2200 |  | PERFILADO Y COMPACTACIÓN EN ZONA DE CORTE | 12d | 2023-10-16 | 2023-10-27 | A2180 SS+1d | 0d |  |  |
| A2230 |  | GEOTEXTIL NO TEJIDO 400 G/M2, INC. COLOCACIÓN | 12d | 2023-10-17 | 2023-10-28 | A2200 SS+1d | 0d |  |  |
| A2240 |  | COLOCACION Y ACOMODO DE ROCA EN UÑA DE DIQUE | 16d | 2023-10-19 | 2023-11-03 | A2230 SS+2d | 0d |  | Roca |
| A2250 |  | COLOCACION Y ACOMODO DE ROCA EN TALUD DE DIQUE | 15d | 2023-10-21 | 2023-11-04 | A2240 SS+2d | 1d | 0d | Roca |
| A2260 |  | PREPARACIÓN DE FUNDACIÓN DE CUERPO DE DIQUE | 5d | 2023-10-24 | 2023-10-28 | A2180 | 1d | 0d |  |
| A2210 |  | CONFORMACIÓN DE CUERPO DE DIQUE CON MATERIAL PROPIO | 5d | 2023-10-25 | 2023-10-29 | A2260 SS+1d, A2120 | 1d | 0d | Relleno |
| A2220 |  | CONFORMACIÓN DE CORONA DE DIQUE CON MATERIAL PROPIO | 6d | 2023-11-02 | 2023-11-07 | A2250 FF+3d, A2130 | 8d | 4d | Relleno |
|  | 3 | **DIQUE DE TIERRA COMPACTADA A3-I-01** |  | 2023-07-11 | 2023-11-13 |  |  |  |  |
|  | 1 | **Sector liberado** |  | 2023-07-11 | 2023-07-28 |  |  |  |  |
| A1440 |  | EXCAVACIÓN EN TERRENO NATURAL CON EQUIPO | 7d | 2023-07-11 | 2023-07-17 | A1240 | 0d |  | Excavación |
| A1450 |  | EXCAVACIÓN DE UÑA CON EQUIPO | 6d | 2023-07-12 | 2023-07-17 | A1440 SS+1d | 65d | 11d | Excavación |
| A1460 |  | PERFILADO Y COMPACTACIÓN EN ZONA DE CORTE | 7d | 2023-07-12 | 2023-07-18 | A1440 SS+1d | 0d |  |  |
| A1520 |  | PREPARACIÓN DE FUNDACIÓN DE CUERPO DE DIQUE | 5d | 2023-07-12 | 2023-07-16 | A1460 SS | 0d |  |  |
| A1470 |  | CONFORMACIÓN DE CUERPO DE DIQUE CON MATERIAL PROPIO | 5d | 2023-07-13 | 2023-07-17 | A1520 SS+1d | 0d |  | Relleno |
| A1490 |  | GEOTEXTIL NO TEJIDO 400 G/M2, INC. COLOCACIÓN | 4d | 2023-07-15 | 2023-07-18 | A1470 SS+2d | 0d |  |  |
| A1500 |  | COLOCACION Y ACOMODO DE ROCA EN UÑA DE DIQUE | 4d | 2023-07-17 | 2023-07-20 | A1490 SS+2d | 0d |  | Roca |
| A1510 |  | COLOCACION Y ACOMODO DE ROCA EN TALUD DE DIQUE | 7d | 2023-07-19 | 2023-07-25 | A1500 SS+2d | 0d |  | Roca |
| A1480 |  | CONFORMACIÓN DE CORONA DE DIQUE CON MATERIAL PROPIO | 3d | 2023-07-26 | 2023-07-28 | A1510 FF+3d | 34d | 18d | Relleno |

| ID | WBS | Activity | Duration | Start | Finish | Predecessors | Total float | Free float | Filtro |
| --- | --- | --- | --- | --- | --- | --- | --- | --- | --- |
|  | 2 | **Sector por Liberar - Km 20+980 - km 21+300** |  | 2023-10-24 | 2023-11-13 |  |  |  |  |
| A4030 |  | EXCAVACIÓN EN TERRENO NATURAL CON EQUIPO | 4d | 2023-10-24 | 2023-10-27 | A2180 | 5d | 0d | Excavación |
| A4040 |  | EXCAVACIÓN DE UÑA CON EQUIPO | 3d | 2023-10-27 | 2023-10-29 | A4030 SS+1d, A2190 | 17d | 0d | Excavación |
| A4050 |  | PERFILADO Y COMPACTACIÓN EN ZONA DE CORTE | 4d | 2023-10-28 | 2023-10-31 | A4030 SS+1d, A2200 | 2d | 0d |  |
| A4110 |  | PREPARACIÓN DE FUNDACIÓN DE CUERPO DE DIQUE | 3d | 2023-10-29 | 2023-10-31 | A4050 SS, A2260 | 1d | 0d |  |
| A4060 |  | CONFORMACIÓN DE CUERPO DE DIQUE CON MATERIAL PROPIO | 3d | 2023-10-30 | 2023-11-01 | A4110 SS+1d, A2210 | 1d | 0d | Relleno |
| A4080 |  | GEOTEXTIL NO TEJIDO 400 G/M2, INC. COLOCACIÓN | 2d | 2023-11-01 | 2023-11-02 | A4060 SS+2d, A2230 | 1d | 0d |  |
| A4090 |  | COLOCACION Y ACOMODO DE ROCA EN UÑA DE DIQUE | 2d | 2023-11-04 | 2023-11-05 | A4080 SS+2d, A2240 | 0d |  | Roca |
| A4100 |  | COLOCACION Y ACOMODO DE ROCA EN TALUD DE DIQUE | 5d | 2023-11-06 | 2023-11-10 | A4090 SS+2d, A2250 | 0d |  | Roca |
| A4070 |  | CONFORMACIÓN DE CORONA DE DIQUE CON MATERIAL PROPIO | 2d | 2023-11-12 | 2023-11-13 | A4100 FF+3d, A2220 | 4d |  | Relleno |
|  | 4 | **DIQUE DE TIERRA COMPACTADA A3-I-02** |  | 2023-07-28 | 2023-08-21 |  |  |  |  |
| A1530 |  | EXCAVACIÓN EN TERRENO NATURAL CON EQUIPO | 15d | 2023-07-28 | 2023-08-11 | A1790 | 0d |  | Excavación |
| A1540 |  | EXCAVACIÓN DE UÑA CON EQUIPO | 14d | 2023-07-29 | 2023-08-11 | A1530 SS+1d, A1450 | 54d | 10d | Excavación |
| A1550 |  | PERFILADO Y COMPACTACIÓN EN ZONA DE CORTE | 11d | 2023-08-01 | 2023-08-11 | A1530 SS+4d | 0d |  |  |
| A1580 |  | GEOTEXTIL NO TEJIDO 400 G/M2, INC. COLOCACIÓN | 11d | 2023-08-03 | 2023-08-13 | A1550 SS+2d | 0d |  |  |
| A1590 |  | COLOCACION Y ACOMODO DE ROCA EN UÑA DE DIQUE | 10d | 2023-08-05 | 2023-08-14 | A1580 SS+2d | 0d |  | Roca |
| A1610 |  | PREPARACIÓN DE FUNDACIÓN DE CUERPO DE DIQUE | 3d | 2023-08-05 | 2023-08-07 | A1530 SS+8d | 77d | 0d |  |
| A1560 |  | CONFORMACIÓN DE CUERPO DE DIQUE CON MATERIAL PROPIO | 3d | 2023-08-06 | 2023-08-08 | A1610 SS+1d | 77d | 20d | Relleno |
| A1600 |  | COLOCACION Y ACOMODO DE ROCA EN TALUD DE DIQUE | 12d | 2023-08-07 | 2023-08-18 | A1590 SS+2d | 0d |  | Roca |
| A1570 |  | CONFORMACIÓN DE CORONA DE DIQUE CON MATERIAL PROPIO | 6d | 2023-08-16 | 2023-08-21 | A1600 FF+3d, A1480 | 16d | 0d | Relleno |
|  | 5 | **DIQUE DE TIERRA COMPACTADA A3-I-03** |  | 2023-08-21 | 2023-11-19 |  |  |  |  |
|  | 1 | **TRAMO 1** |  | 2023-08-21 | 2023-09-13 |  |  |  |  |
| A1620 |  | EXCAVACIÓN EN TERRENO NATURAL CON EQUIPO | 7d | 2023-08-21 | 2023-08-27 | A2630 | 0d |  | Excavación |
| A1630 |  | EXCAVACIÓN DE UÑA CON EQUIPO | 11d | 2023-08-22 | 2023-09-01 | A1620 SS+1d, A1540 | 44d | 12d | Excavación |
| A1640 |  | PERFILADO Y COMPACTACIÓN EN ZONA DE CORTE | 12d | 2023-08-22 | 2023-09-02 | A1620 SS+1d | 0d |  |  |
| A1670 |  | GEOTEXTIL NO TEJIDO 400 G/M2, INC. COLOCACIÓN | 12d | 2023-08-23 | 2023-09-03 | A1640 SS+1d | 0d |  |  |
| A1680 |  | COLOCACION Y ACOMODO DE ROCA EN UÑA DE DIQUE | 16d | 2023-08-25 | 2023-09-09 | A1670 SS+2d | 0d |  | Roca |
| A1690 |  | COLOCACION Y ACOMODO DE ROCA EN TALUD DE DIQUE | 15d | 2023-08-27 | 2023-09-10 | A1680 SS+2d | 0d |  | Roca |
| A1700 |  | PREPARACIÓN DE FUNDACIÓN DE CUERPO DE DIQUE | 5d | 2023-08-28 | 2023-09-01 | A1620 | 57d | 0d |  |
| A1650 |  | CONFORMACIÓN DE CUERPO DE DIQUE CON MATERIAL PROPIO | 5d | 2023-08-29 | 2023-09-02 | A1700 SS+1d, A1560 | 57d | 15d | Relleno |
| A1660 |  | CONFORMACIÓN DE CORONA DE DIQUE CON MATERIAL PROPIO | 6d | 2023-09-08 | 2023-09-13 | A1690 FF+3d, A1570 | 52d | 14d | Relleno |

| ID | WBS | Activity | Duration | Start | Finish | Predecessors | Total float | Free float | Filtro |
| --- | --- | --- | --- | --- | --- | --- | --- | --- | --- |
|  | 2 | **TRAMO 2** |  | 2023-09-13 | 2023-11-19 |  |  |  |  |
|  | 1 | **Sector liberado** |  | 2023-09-13 | 2023-09-30 |  |  |  |  |
| A2270 |  | EXCAVACIÓN EN TERRENO NATURAL CON EQUIPO | 4d | 2023-09-13 | 2023-09-16 | A2650 | 0d |  | Excavación |
| A2280 |  | EXCAVACIÓN DE UÑA CON EQUIPO | 7d | 2023-09-14 | 2023-09-20 | A2270 SS+1d, A1630 | 32d | 10d | Excavación |
| A2290 |  | PERFILADO Y COMPACTACIÓN EN ZONA DE CORTE | 8d | 2023-09-14 | 2023-09-21 | A2270 SS+1d | 0d |  |  |
| A2320 |  | GEOTEXTIL NO TEJIDO 400 G/M2, INC. COLOCACIÓN | 7d | 2023-09-15 | 2023-09-21 | A2290 SS+1d | 0d |  |  |
| A2330 |  | COLOCACION Y ACOMODO DE ROCA EN UÑA DE DIQUE | 10d | 2023-09-17 | 2023-09-26 | A2320 SS+2d | 0d |  | Roca |
| A2350 |  | PREPARACIÓN DE FUNDACIÓN DE CUERPO DE DIQUE | 3d | 2023-09-17 | 2023-09-19 | A2270 | 42d | 0d |  |
| A2300 |  | CONFORMACIÓN DE CUERPO DE DIQUE CON MATERIAL PROPIO | 3d | 2023-09-18 | 2023-09-20 | A2350 SS+1d, A1650 | 42d | 17d | Relleno |
| A2340 |  | COLOCACION Y ACOMODO DE ROCA EN TALUD DE DIQUE | 9d | 2023-09-19 | 2023-09-27 | A2330 SS+2d | 0d |  | Roca |
| A2310 |  | CONFORMACIÓN DE CORONA DE DIQUE CON MATERIAL PROPIO | 3d | 2023-09-28 | 2023-09-30 | A2340 FF+3d, A1660 | 38d | 17d | Relleno |
|  | 2 | **Sector por Liberar - Km 23+760 - km 24+100** |  | 2023-10-28 | 2023-11-19 |  |  |  |  |
| A4120 |  | EXCAVACIÓN EN TERRENO NATURAL CON EQUIPO | 3d | 2023-10-28 | 2023-10-30 | A4030 | 8d | 1d | Excavación |
| A4130 |  | EXCAVACIÓN DE UÑA CON EQUIPO | 4d | 2023-10-30 | 2023-11-02 | A4120 SS+1d, A4040 | 17d |  | Excavación |
| A4140 |  | PERFILADO Y COMPACTACIÓN EN ZONA DE CORTE | 5d | 2023-11-01 | 2023-11-05 | A4120 SS+1d, A4050 | 5d | 1d |  |
| A4200 |  | PREPARACIÓN DE FUNDACIÓN DE CUERPO DE DIQUE | 2d | 2023-11-01 | 2023-11-02 | A4120, A4110 | 16d | 0d |  |
| A4150 |  | CONFORMACIÓN DE CUERPO DE DIQUE CON MATERIAL PROPIO | 2d | 2023-11-02 | 2023-11-03 | A4200 SS+1d, A4060 | 16d |  | Relleno |
| A4170 |  | GEOTEXTIL NO TEJIDO 400 G/M2, INC. COLOCACIÓN | 3d | 2023-11-03 | 2023-11-05 | A4140 SS+1d, A4080 | 4d | 1d |  |
| A4180 |  | COLOCACION Y ACOMODO DE ROCA EN UÑA DE DIQUE | 7d | 2023-11-06 | 2023-11-12 | A4170 SS+2d, A4090 | 3d |  | Roca |
| A4190 |  | COLOCACION Y ACOMODO DE ROCA EN TALUD DE DIQUE | 6d | 2023-11-11 | 2023-11-16 | A4180 SS+2d, A4100 | 0d |  | Roca |
| A4160 |  | CONFORMACIÓN DE CORONA DE DIQUE CON MATERIAL PROPIO | 2d | 2023-11-18 | 2023-11-19 | A4190 FF+3d, A4070 | 0d |  | Relleno |
|  | 3 | **TRAMO 3** |  | 2023-09-30 | 2023-10-23 |  |  |  |  |
| A2360 |  | EXCAVACIÓN EN TERRENO NATURAL CON EQUIPO | 7d | 2023-09-30 | 2023-10-06 | A2670 | 0d |  | Excavación |
| A2370 |  | EXCAVACIÓN DE UÑA CON EQUIPO | 11d | 2023-10-01 | 2023-10-11 | A2360 SS+1d, A2280 | 22d | 12d | Excavación |
| A2380 |  | PERFILADO Y COMPACTACIÓN EN ZONA DE CORTE | 12d | 2023-10-01 | 2023-10-12 | A2360 SS+1d | 0d |  |  |
| A2410 |  | GEOTEXTIL NO TEJIDO 400 G/M2, INC. COLOCACIÓN | 12d | 2023-10-02 | 2023-10-13 | A2380 SS+1d | 0d |  |  |
| A2420 |  | COLOCACION Y ACOMODO DE ROCA EN UÑA DE DIQUE | 16d | 2023-10-04 | 2023-10-19 | A2410 SS+2d | 0d |  | Roca |
| A2430 |  | COLOCACION Y ACOMODO DE ROCA EN TALUD DE DIQUE | 15d | 2023-10-06 | 2023-10-20 | A2420 SS+2d | 0d |  | Roca |
| A2440 |  | PREPARACIÓN DE FUNDACIÓN DE CUERPO DE DIQUE | 5d | 2023-10-07 | 2023-10-11 | A2360 | 25d | 0d |  |
| A2390 |  | CONFORMACIÓN DE CUERPO DE DIQUE CON MATERIAL PROPIO | 5d | 2023-10-08 | 2023-10-12 | A2440 SS+1d, A2300 | 25d | 18d | Relleno |
| A2400 |  | CONFORMACIÓN DE CORONA DE DIQUE CON MATERIAL PROPIO | 6d | 2023-10-18 | 2023-10-23 | A2430 FF+3d, A2310 | 21d | 17d | Relleno |

| ID | WBS | Activity | Duration | Start | Finish | Predecessors | Total float | Free float | Filtro |
| --- | --- | --- | --- | --- | --- | --- | --- | --- | --- |
|  | 4 | **TRAMO 4** |  | 2023-10-23 | 2023-11-15 |  |  |  |  |
| A2450 |  | EXCAVACIÓN EN TERRENO NATURAL CON EQUIPO | 7d | 2023-10-23 | 2023-10-29 | A2690 | 0d |  | Excavación |
| A2460 |  | EXCAVACIÓN DE UÑA CON EQUIPO | 11d | 2023-10-24 | 2023-11-03 | A2450 SS+1d, A2370 | 10d | 0d | Excavación |
| A2470 |  | PERFILADO Y COMPACTACIÓN EN ZONA DE CORTE | 12d | 2023-10-24 | 2023-11-04 | A2450 SS+1d | 0d |  |  |
| A2500 |  | GEOTEXTIL NO TEJIDO 400 G/M2, INC. COLOCACIÓN | 12d | 2023-10-25 | 2023-11-05 | A2470 SS+1d | 0d |  |  |
| A2510 |  | COLOCACION Y ACOMODO DE ROCA EN UÑA DE DIQUE | 16d | 2023-10-27 | 2023-11-11 | A2500 SS+2d | 0d |  | Roca |
| A2520 |  | COLOCACION Y ACOMODO DE ROCA EN TALUD DE DIQUE | 15d | 2023-10-29 | 2023-11-12 | A2510 SS+2d | 0d |  | Roca |
| A2530 |  | PREPARACIÓN DE FUNDACIÓN DE CUERPO DE DIQUE | 5d | 2023-10-30 | 2023-11-03 | A2450 | 7d | 0d |  |
| A2480 |  | CONFORMACIÓN DE CUERPO DE DIQUE CON MATERIAL PROPIO | 5d | 2023-10-31 | 2023-11-04 | A2530 SS+1d, A2390 | 7d | 4d | Relleno |
| A2490 |  | CONFORMACIÓN DE CORONA DE DIQUE CON MATERIAL PROPIO | 6d | 2023-11-10 | 2023-11-15 | A2520 FF+3d, A2400 | 4d |  | Relleno |
|  | 6 | **RAMPAS** |  | 2023-10-27 | 2023-11-09 |  |  |  |  |
|  | 1 | **A3-RA-D-01** |  | 2023-10-27 | 2023-11-01 |  |  |  |  |
| A1710 |  | EXCAVACIÓN EN TERRENO NATURAL CON EQUIPO | 3d | 2023-10-27 | 2023-10-29 | A2190 | 15d | 0d | Excavación |
| A1720 |  | CONFORMACIÓN DE CUERPO DE RAMPA CON MATERIAL PROPIO | 3d | 2023-10-30 | 2023-11-01 | A1710 | 15d | 0d | Relleno |
| A1730 |  | CONFORMACIÓN DE CORONACIÓN DE RAMPA | 3d | 2023-10-30 | 2023-11-01 | A1720 SS | 15d | 5d | Relleno |
|  | 2 | **A3-RA-I-01** |  | 2023-11-04 | 2023-11-09 |  |  |  |  |
| A1740 |  | EXCAVACIÓN EN TERRENO NATURAL CON EQUIPO | 3d | 2023-11-04 | 2023-11-06 | A2460 | 10d | 0d | Excavación |
| A1750 |  | CONFORMACIÓN DE CUERPO DE RAMPA CON MATERIAL PROPIO | 3d | 2023-11-07 | 2023-11-09 | A1740 | 10d | 0d | Relleno |
| A1760 |  | CONFORMACIÓN DE CORONACIÓN DE RAMPA | 3d | 2023-11-07 | 2023-11-09 | A1750 SS, A1730 | 10d |  | Relleno |
|  | 2 | **OBRAS DE ARTE** |  | 2023-06-01 | 2023-11-16 |  |  |  |  |
|  | 1 | **CAPTACIÓN A3-CP-23-95** |  | 2023-06-16 | 2023-10-12 |  |  |  |  |
|  | 1 | **MOVIMIENTO DE TIERRAS** |  | 2023-06-16 | 2023-08-02 |  |  |  |  |
| A2770 |  | EXCAVACIÓN ESTRUCTURAL PARA OBRAS DE ARTE | 6d | 2023-06-16 | 2023-06-21 | A3390 | 38d | 0d |  |
| A2780 |  | RELLENO ESTRUCTURAL PARA OBRAS DE ARTE, CON MATERIAL PROPIO | 5d | 2023-07-29 | 2023-08-02 | A2800 FS+12d | 90d | 1d |  |

| ID | WBS | Activity | Duration | Start | Finish | Predecessors | Total float | Free float |
| --- | --- | --- | --- | --- | --- | --- | --- | --- |
|  | 2 | **OBRAS DE CONCRETO** |  | 2023-06-22 | 2023-07-16 |  |  |  |
| A2790 |  | CONCRETO f'c=100 kg/cm2 | 3d | 2023-06-22 | 2023-06-24 | A2770 | 50d | 0d |
| A2810 |  | CONCRETO CICLÓPEO f'c=280 kg/cm2 + 30% P.G. | 3d | 2023-06-25 | 2023-06-27 | A2790 | 50d | 0d |
| A2830 |  | ACERO DE REFUERZO fy=4200 kg/cm2 | 13d | 2023-06-28 | 2023-07-10 | A2810 | 50d | 0d |
| A2820 |  | ENCOFRADO Y DESENCOFRADO RECTO | 10d | 2023-07-02 | 2023-07-11 | A2830 FF+1d | 53d | 0d |
| A2800 |  | CONCRETO f'c=280 kg/cm2 | 12d | 2023-07-05 | 2023-07-16 | A2820 SS+3d | 55d | 0d |
|  | 3 | **ESTRUCTURAS METALICAS** |  | 2023-07-29 | 2023-08-12 |  |  |  |
| A2840 |  | COMPUERTA METALICA PLANA DESLIZANTE DE 1.0x1.0m | 3d | 2023-07-29 | 2023-07-31 | A2800 FS+12d | 99d | 0d |
| A2850 |  | REJILLA DE 1.00x1.00m CON VARILLA DE 1/2" CADA 6,25cm | 3d | 2023-08-01 | 2023-08-03 | A2840 | 99d | 0d |
| A2860 |  | BARANDA DE FIERRO GALVANIZADO 1 1/2" | 3d | 2023-08-04 | 2023-08-06 | A2850 | 99d | 0d |
| A2870 |  | ESCALERA TIPO GATO | 3d | 2023-08-07 | 2023-08-09 | A2860 | 99d | 0d |
| A2880 |  | TAPA METALICA CIRCULAR DN600 MM | 3d | 2023-08-10 | 2023-08-12 | A2870 | 99d |  |
|  | 4 | **TUBERIAS** |  | 2023-06-22 | 2023-08-18 |  |  |  |
| A2890 |  | EXCAVACIÓN ESTRUCTURAL PARA OBRAS DE ARTE (Buzones) | 3d | 2023-06-22 | 2023-06-24 | A2770 | 38d | 0d |
| A2900 |  | EXCAVACIÓN DE ZANJA | 25d | 2023-06-25 | 2023-07-19 | A2890 | 38d | 0d |
| A2920 |  | CAMA DE ARENA | 25d | 2023-06-28 | 2023-07-22 | A2900 SS+3d | 93d | 0d |
| A2940 |  | CONCRETO f'c=100 kg/cm2 (Buzones) | 3d | 2023-06-28 | 2023-06-30 | A2900 SS+3d, A2790 | 60d | 10d |
| A2990 |  | SUMINISTRO E INSTALACIÓN DE TUBERÍA GRP DN600 mm SN2500 | 25d | 2023-06-29 | 2023-07-23 | A2920 SS+1d | 93d | 0d |
| A2980 |  | ACERO DE REFUERZO fy=4200 kg/cm2 (Buzones) | 4d | 2023-07-11 | 2023-07-14 | A2940, A2830 | 50d | 0d |
| A2960 |  | ENCOFRADO Y DESENCOFRADO RECTO | 5d | 2023-07-15 | 2023-07-19 | A2820, A2980 | 50d | 0d |
| A2970 |  | ENCOFRADO Y DESENCOFRADO CURVO | 5d | 2023-07-15 | 2023-07-19 | A2960 SS | 50d | 0d |
| A2950 |  | CONCRETO f'c=280 kg/cm2 (Buzones) | 3d | 2023-07-20 | 2023-07-22 | A2970, A2800 | 52d | 0d |
| A2930 |  | RELLENO COMÚN PARA ZANJAS | 26d | 2023-07-24 | 2023-08-18 | A2990 | 93d |  |
| A2910 |  | RELLENO ESTRUCTURAL PARA OBRAS DE ARTE CON MATERIAL PROPIO (Buzones) | 3d | 2023-08-04 | 2023-08-06 | A2950 FS+12d, A2780 | 89d | 0d |

| ID | WBS | Activity | Duration | Start | Finish | Predecessors | Total float | Free float |
| --- | --- | --- | --- | --- | --- | --- | --- | --- |
|  | 5 | **CANAL** |  | 2023-07-20 | 2023-09-24 |  |  |  |
| A3000 |  | EXCAVACIÓN ESTRUCTURAL PARA OBRAS DE ARTE | 6d | 2023-07-20 | 2023-07-25 | A2900 | 38d | 0d |
| A3020 |  | COLOCACIÓN DE CONCRETO f'c=100 kg/cm2 | 4d | 2023-07-26 | 2023-07-29 | A2940, A3000 | 38d | 0d |
| A3050 |  | ACERO DE REFUERZO fy=4200 kg/cm2 | 28d | 2023-07-30 | 2023-08-26 | A2980, A3020 | 38d | 0d |
| A3040 |  | ENCOFRADO Y DESENCOFRADO RECTO | 52d | 2023-08-01 | 2023-09-21 | A2970, A3050 SS+2d | 38d | 0d |
| A3030 |  | COLOCACIÓN DE CONCRETO f'c=280 kg/cm2 | 53d | 2023-08-03 | 2023-09-24 | A2950 SS, A3040 SS+2d | 38d | 0d |
| A3060 |  | JUNTA WATER STOP SIN BULBO 150 mm | 53d | 2023-08-03 | 2023-09-24 | A3030 SS | 53d | 3d |
| A3010 |  | RELLENO ESTRUCTURAL PARA CANALES, CON MATERIAL PROPIO | 13d | 2023-08-07 | 2023-08-19 | A2910 | 89d | 51d |
|  | 6 | **OBRAS DE DESCARGA** |  | 2023-07-26 | 2023-10-12 |  |  |  |
| A3070 |  | EXCAVACIÓN ESTRUCTURAL PARA OBRAS DE ARTE | 3d | 2023-07-26 | 2023-07-28 | A3000 | 87d | 1d |
| A3090 |  | CONCRETO f'c=100 kg/cm2 | 3d | 2023-07-30 | 2023-08-01 | A3070, A3020 | 86d | 25d |
| A3120 |  | ACERO DE REFUERZO fy=4200 kg/cm2 | 3d | 2023-08-27 | 2023-08-29 | A3090, A3050 | 61d | 23d |
| A3110 |  | ENCOFRADO Y DESENCOFRADO RECTO | 3d | 2023-09-22 | 2023-09-24 | A3120, A3040 | 38d | 0d |
| A3100 |  | CONCRETO f'c=280 kg/cm2 | 3d | 2023-09-25 | 2023-09-27 | A3110, A3030 | 38d | 0d |
| A3130 |  | JUNTA WATER STOP SIN BULBO 150 mm | 3d | 2023-09-28 | 2023-09-30 | A3100, A3060 | 50d |  |
| A3080 |  | RELLENO ESTRUCTURAL PARA OBRAS DE ARTE CON MATERIAL PROPIO | 3d | 2023-10-10 | 2023-10-12 | A3100 FS+12d, A3010 | 38d |  |
| A3140 |  | COMPUERTA METALICA PLANA DESLIZANTE | 3d | 2023-10-10 | 2023-10-12 | A3100 FS+12d | 38d |  |
|  | 2 | **CAPTACIÓN A3-CP-21-05** |  | 2023-06-04 | 2023-09-01 |  |  |  |
|  | 1 | **MOVIMIENTO DE TIERRAS** |  | 2023-06-04 | 2023-07-23 |  |  |  |
| A3150 |  | EXCAVACIÓN ESTRUCTURAL PARA OBRAS DE ARTE | 4d | 2023-06-04 | 2023-06-07 | A1070 SS+7d | 38d | 0d |
| A3160 |  | RELLENO ESTRUCTURAL PARA OBRAS DE ARTE, CON MATERIAL PROPIO | 5d | 2023-07-19 | 2023-07-23 | A3180 FS+12d | 119d |  |
|  | 2 | **OBRAS DE CONCRETO** |  | 2023-06-08 | 2023-07-06 |  |  |  |
| A3170 |  | CONCRETO f'c=100 kg/cm2 | 3d | 2023-06-08 | 2023-06-10 | A3150 | 79d | 0d |
| A3190 |  | CONCRETO CICLÓPEO f'c=280 kg/cm2 + 30% P.G. | 3d | 2023-06-11 | 2023-06-13 | A3170 | 79d | 0d |
| A3210 |  | ACERO DE REFUERZO fy=4200 kg/cm2 | 21d | 2023-06-14 | 2023-07-04 | A3190 | 79d | 0d |
| A3200 |  | ENCOFRADO Y DESENCOFRADO RECTO | 15d | 2023-06-20 | 2023-07-04 | A3210 SS+6d | 82d | 0d |
| A3180 |  | CONCRETO f'c=280 kg/cm2 | 11d | 2023-06-26 | 2023-07-06 | A3200 SS+6d | 109d | 0d |

| ID | WBS | Activity | Duration | Start | Finish | Predecessors | Total float | Free float |
| --- | --- | --- | --- | --- | --- | --- | --- | --- |
|  | 3 | **ESTRUCTURAS METALICAS** |  | 2023-07-19 | 2023-08-02 |  |  |  |
| A3220 |  | COMPUERTA METALICA PLANA DESLIZANTE DE 1.0x1.0m | 3d | 2023-07-19 | 2023-07-21 | A3180 FS+12d | 109d | 0d |
| A3230 |  | REJILLA DE 1.00x1.00m CON VARILLA DE 1/2 CADA 6,25cm | 3d | 2023-07-22 | 2023-07-24 | A3220 | 109d | 0d |
| A3240 |  | BARANDA DE FIERRO GALVANIZADO 1 1/2" | 3d | 2023-07-25 | 2023-07-27 | A3230 | 109d | 0d |
| A3250 |  | ESCALERA TIPO GATO | 3d | 2023-07-28 | 2023-07-30 | A3240 | 109d | 0d |
| A3260 |  | TAPA METALICA CIRCULAR DN600 MM | 3d | 2023-07-31 | 2023-08-02 | A3250 | 109d |  |
|  | 4 | **TUBERIA** |  | 2023-06-08 | 2023-07-28 |  |  |  |
| A3270 |  | EXCAVACIÓN ESTRUCTURAL PARA OBRAS DE ARTE (Buzones) | 3d | 2023-06-08 | 2023-06-10 | A3150 | 38d | 0d |
| A3280 |  | EXCAVACIÓN DE ZANJA | 3d | 2023-06-11 | 2023-06-13 | A3270 | 143d | 0d |
| A3330 |  | CONCRETO f'c=100 kg/cm2 (Buzones) | 3d | 2023-06-11 | 2023-06-13 | A3270, A3170 | 100d | 2d |
| A3300 |  | CAMA DE ARENA | 3d | 2023-06-14 | 2023-06-16 | A3280 | 143d | 0d |
| A3380 |  | SUMINISTRO E INSTALACIÓN DE TUBERÍA GRP DN600 mm SN2500 | 3d | 2023-06-17 | 2023-06-19 | A3300 | 143d | 0d |
| A3310 |  | RELLENO SELECCIONADO PARA ZANJAS CON MATERIAL PROPIO | 3d | 2023-06-20 | 2023-06-22 | A3320 SS | 143d | 64d |
| A3320 |  | RELLENO COMÚN PARA ZANJAS | 3d | 2023-06-20 | 2023-06-22 | A3380 | 143d | 0d |
| A3370 |  | ACERO DE REFUERZO fy=4200 kg/cm2 | 3d | 2023-07-05 | 2023-07-07 | A3330, A3210 | 79d | 0d |
| A3350 |  | ENCOFRADO Y DESENCOFRADO RECTO | 3d | 2023-07-08 | 2023-07-10 | A3370, A3200 | 79d | 0d |
| A3360 |  | ENCOFRADO Y DESENCOFRADO CURVO | 3d | 2023-07-08 | 2023-07-10 | A3350 SS | 79d | 0d |
| A3340 |  | CONCRETO f'c=280 kg/cm2 (Buzones) | 3d | 2023-07-11 | 2023-07-13 | A3360, A3180 | 105d | 0d |
| A3290 |  | RELLENO ESTRUCTURAL PARA OBRAS DE ARTE CON MATERIAL PROPIO | 3d | 2023-07-26 | 2023-07-28 | A3340 FS+12d | 107d | 28d |
|  | 5 | **CANALES** |  | 2023-06-11 | 2023-09-01 |  |  |  |
| A3390 |  | EXCAVACIÓN ESTRUCTURAL PARA OBRAS DE ARTE | 5d | 2023-06-11 | 2023-06-15 | A3270 | 38d | 0d |
| A3410 |  | COLOCACIÓN DE CONCRETO f'c=100 kg/cm2 | 3d | 2023-06-16 | 2023-06-18 | A3390, A3330 | 98d | 19d |
| A3440 |  | ACERO DE REFUERZO fy=4200 kg/cm2 | 12d | 2023-07-08 | 2023-07-19 | A3410, A3370 | 79d | 0d |
| A3430 |  | ENCOFRADO Y DESENCOFRADO | 29d | 2023-07-11 | 2023-08-08 | A3440 SS+3d, A3360 | 79d | 0d |
| A3420 |  | COLOCACIÓN DE CONCRETO f'c=280 kg/cm2 | 5d | 2023-08-09 | 2023-08-13 | A3430, A3340 | 79d | 0d |
| A3450 |  | JUNTA WATER STOP SIN BULBO 150 mm | 3d | 2023-08-09 | 2023-08-11 | A3420 SS | 100d |  |
| A3400 |  | RELLENO ESTRUCTURAL PARA CANALES, CON MATERIAL PROPIO | 7d | 2023-08-26 | 2023-09-01 | A3420 FS+12d, A3290, A3310 | 79d |  |

| ID | WBS | Activity | Duration | Start | Finish | Predecessors | Total float | Free float |
| --- | --- | --- | --- | --- | --- | --- | --- | --- |
|  | 3 | **RETORNO A3-OA-RE-D-21-55** |  | 2023-06-01 | 2023-07-24 |  |  |  |
|  | 1 | **MOVIMIENTO DE TIERRAS** |  | 2023-06-01 | 2023-07-20 |  |  |  |
| A3460 |  | EXCAVACIÓN ESTRUCTURAL PARA OBRAS DE ARTE | 3d | 2023-06-01 | 2023-06-03 | A1070 SS+4d | 118d | 0d |
| A3470 |  | RELLENO ESTRUCTURAL PARA OBRAS DE ARTE, CON MATERIAL PROPIO | 3d | 2023-07-18 | 2023-07-20 | A3490 FS+12d | 122d |  |
|  | 2 | **OBRAS DE CONCRETO** |  | 2023-06-04 | 2023-07-05 |  |  |  |
| A3480 |  | CONCRETO f'c=100 kg/cm2 | 3d | 2023-06-04 | 2023-06-06 | A3460 | 118d | 0d |
| A3500 |  | CONCRETO CICLÓPEO f'c=280 kg/cm2 + 30% P.G. | 5d | 2023-06-07 | 2023-06-11 | A3480 | 118d | 0d |
| A3520 |  | ACERO DE REFUERZO fy=4200 kg/cm2 | 24d | 2023-06-07 | 2023-06-30 | A3500 SS | 118d | 0d |
| A3510 |  | ENCOFRADO Y DESENCOFRADO | 18d | 2023-06-13 | 2023-06-30 | A3520 SS+6d | 118d | 0d |
| A3490 |  | CONCRETO f'c=280 kg/cm2 | 5d | 2023-07-01 | 2023-07-05 | A3510 | 118d | 0d |
| A3530 |  | JUNTA WATER STOP SIN BULBO 150 mm | 5d | 2023-07-01 | 2023-07-05 | A3490 SS | 137d |  |
|  | 3 | **ESTRUCTURAS METALICAS** |  | 2023-07-18 | 2023-07-24 |  |  |  |
| A3540 |  | COMPUERTA METALICA PLANA DESLIZANTE DE 1.0x1.6 m | 4d | 2023-07-18 | 2023-07-21 | A3490 FS+12d | 118d | 0d |
| A3550 |  | BARANDA DE FIERRO GALVANIZADO 1 1/2" | 3d | 2023-07-22 | 2023-07-24 | A3540 | 118d |  |
|  | 4 | **REPOSICIÓN DE CANALES** |  | 2023-06-18 | 2023-11-16 |  |  |  |
|  | 1 | **REPOSICIÓN DE CANAL 1** |  | 2023-08-12 | 2023-11-16 |  |  |  |
|  | 1 | **MOVIMIENTO DE TIERRAS** |  | 2023-08-12 | 2023-11-16 |  |  |  |
| A3560 |  | DEMOLICIÓN DE ESTRUCTURAS EXISTENTES | 17d | 2023-08-12 | 2023-08-28 | A1530 | 83d |  |
| A3570 |  | EXCAVACIÓN EN TERRENO NATURAL CON EQUIPO | 36d | 2023-08-19 | 2023-09-23 | A1600 | 3d | 0d |
| A3580 |  | RELLENO ESTRUCTURAL PARA OBRAS DE ARTE CON MATERIAL PROPIO | 39d | 2023-10-09 | 2023-11-16 | A3620 SS+20d, A3670 | 3d |  |
|  | 2 | **OBRAS DE CONCRETO** |  | 2023-08-26 | 2023-11-14 |  |  |  |
| A3610 |  | CONCRETO f'c=100 kg/cm2 | 36d | 2023-08-26 | 2023-09-30 | A3570 SS+7d | 3d | 0d |
| A3600 |  | ACERO DE REFUERZO fy=4200 kg/cm2 | 70d | 2023-08-29 | 2023-11-06 | A3610 SS+3d | 3d | 0d |
| A3590 |  | ENCOFRADO Y DESENCOFRADO RECTO | 63d | 2023-09-05 | 2023-11-06 | A3600 SS+7d | 3d | 0d |
| A3620 |  | CONCRETO f'c=280 kg/cm2 | 54d | 2023-09-19 | 2023-11-11 | A3590 SS+14d | 3d | 0d |
| A3630 |  | JUNTA WATER STOP 6" | 54d | 2023-09-19 | 2023-11-11 | A3620 SS | 8d |  |
| A3640 |  | MAMPOSTERIA DE PIEDRA, e=20cm, ACABADO CARA VISTA | 3d | 2023-11-12 | 2023-11-14 | A3620 | 5d |  |

| ID | WBS | Activity | Duration | Start | Finish | Predecessors | Total float | Free float |
| --- | --- | --- | --- | --- | --- | --- | --- | --- |
|  | 2 | **REPOSICIÓN DE CANAL 3** |  | 2023-06-18 | 2023-08-14 |  |  |  |
|  | 1 | **MOVIMIENTO DE TIERRAS** |  | 2023-06-18 | 2023-08-14 |  |  |  |
| A3650 |  | DEMOLICIÓN DE ESTRUCTURAS EXISTENTES | 10d | 2023-06-18 | 2023-06-27 | A1260 | 69d | 11d |
| A3660 |  | EXCAVACIÓN EN TERRENO NATURAL CON EQUIPO | 4d | 2023-07-09 | 2023-07-12 | A1330, A3650 | 58d | 0d |
| A3670 |  | RELLENO ESTRUCTURAL PARA OBRAS DE ARTE CON MATERIAL PROPIO | 3d | 2023-08-12 | 2023-08-14 | A3720 FS+6d | 58d | 55d |
|  | 2 | **OBRAS DE CONCRETO** |  | 2023-07-13 | 2023-08-08 |  |  |  |
| A3710 |  | CONCRETO f'c=100 kg/cm2 | 4d | 2023-07-13 | 2023-07-16 | A3660 | 58d | 0d |
| A3700 |  | MALLA ELECTROSOLDADA DE DN6mm EN CUADRICULA 15x15 cm | 15d | 2023-07-17 | 2023-07-31 | A3710 | 58d | 0d |
| A3680 |  | ENCOFRADO Y DESENCOFRADO PARA REVESTIMIENTO DE CANALES (CERCHAS) | 12d | 2023-07-20 | 2023-07-31 | A3700 SS+3d | 58d | 0d |
| A3690 |  | ENCOFRADO Y DESENCOFRADO RECTO | 12d | 2023-07-20 | 2023-07-31 | A3680 SS | 58d | 0d |
| A3730 |  | SELLO DE JUNTA CONSTRUCCIÓN CON MATERIAL ELASTOMÉRICO | 10d | 2023-07-20 | 2023-07-29 | A3680 SS | 113d |  |
| A3720 |  | CONCRETO f'c=280 kg/cm2 | 5d | 2023-08-01 | 2023-08-05 | A3690 | 58d | 0d |
| A3740 |  | MAMPOSTERIA DE PIEDRA, e=20cm, ACABADO CARA VISTA | 3d | 2023-08-06 | 2023-08-08 | A3720 | 103d |  |
|  | 5 | **REPOSICIÓN SIFON INOPERATIVO** |  | 2023-07-04 | 2023-08-12 |  |  |  |
| A3750 |  | DEMOLICIÓN DE ESTRUCTURAS EXISTENTES | 3d | 2023-07-04 | 2023-07-06 | A1230, A1880 | 99d | 0d |
| A3760 |  | EXCAVACIÓN ESTRUCTURAL PARA OBRAS DE ARTE | 10d | 2023-07-07 | 2023-07-16 | A3750 | 99d | 0d |
| A3770 |  | COLOCACIÓN CAMA DE ARENA | 3d | 2023-07-17 | 2023-07-19 | A3760 | 108d | 0d |
| A3810 |  | CONCRETO f'c=100 kg/cm2 | 3d | 2023-07-17 | 2023-07-19 | A3760 | 99d | 0d |
| A3800 |  | TUBERÍAS DE 14" HDPE SDR21 DN 355mm | 6d | 2023-07-20 | 2023-07-25 | A3770 | 108d | 0d |
| A3840 |  | ACERO DE REFUERZO fy=4200 kg/cm2 | 3d | 2023-07-20 | 2023-07-22 | A3810 | 99d | 0d |
| A3850 |  | CODOS HDPE DE 14" DN 355mm | 6d | 2023-07-20 | 2023-07-25 | A3800 SS | 117d |  |
| A3830 |  | ENCOFRADO Y DESENCOFRADO RECTO | 3d | 2023-07-23 | 2023-07-25 | A3840 | 99d | 0d |
| A3790 |  | RELLENO COMÚN | 9d | 2023-07-26 | 2023-08-03 | A3800 | 108d |  |
| A3820 |  | CONCRETO f'c=280 kg/cm2 | 3d | 2023-07-26 | 2023-07-28 | A3830 | 99d | 0d |
| A3780 |  | RELLENO ESTRUCTURAL PARA OBRAS DE ARTE CON MATERIAL PROPIO | 3d | 2023-08-10 | 2023-08-12 | A3820 FS+12d | 99d |  |

| ID | WBS | Activity | Duration | Start | Finish | Predecessors | Total float | Free float | Filtro |
| --- | --- | --- | --- | --- | --- | --- | --- | --- | --- |
|  | 3 | **ARQUITECTURA Y PAISAJISMO** |  | 2023-08-22 | 2023-11-03 |  |  |  |  |
|  | 1 | **OBRAS PRELIMINARES** |  | 2023-08-22 | 2023-11-03 |  |  |  |  |
| A3860 |  | MOVILIZACIÓN DE EQUIPOS Y HERRAMIENTAS (ARQUITECTURA Y PAISAJISMO) | 2d | 2023-08-22 | 2023-08-23 | A1570 | 16d | 0d |  |
| A3870 |  | TRAZO Y REPLANTEO PRELIMINAR | 2d | 2023-08-24 | 2023-08-25 | A3860 | 16d | 0d |  |
| A4020 |  | DEMOVILIZACIÓN DE EQUIPOS Y HERRAMIENTAS (ARQUITECTURA Y PAISAJISMO) | 2d | 2023-11-02 | 2023-11-03 | A4010, A3900 | 16d |  |  |
|  | 2 | **MOVIMIENTO DE TIERRAS** |  | 2023-08-26 | 2023-09-11 |  |  |  |  |
| A3880 |  | EXCAVACIÓN MANUAL PARA INSTALACIÓN DE BORDILLOS Y CIMENTACIONES | 2d | 2023-08-26 | 2023-08-27 | A3870 | 16d | 0d |  |
| A3900 |  | ELIMINACION DE MATERIAL EXCEDENTE (DME´S) | 17d | 2023-08-26 | 2023-09-11 | A3880 SS | 67d | 51d |  |
| A3890 |  | EXCAVACIÓN PARA MEJORAMIENTO DE SUELO CON TIERRA VEGETAL | 15d | 2023-08-28 | 2023-09-11 | A3880 | 16d | 0d |  |
|  | 3 | **PAVIMENTOS, RECUBRIMIENTOS Y BORDILLOS** |  | 2023-09-12 | 2023-09-22 |  |  |  |  |
| A3910 |  | PISO DE GRAVILLA | 2d | 2023-09-12 | 2023-09-13 | A3890 | 16d | 0d |  |
| A3920 |  | RECUBRIMIENTO DE PIEDRA DEL LUGAR e=0.05cm | 4d | 2023-09-14 | 2023-09-17 | A3910 | 16d | 0d |  |
| A3930 |  | BORDILLOS DE PIEDRA DEL LUGAR | 5d | 2023-09-18 | 2023-09-22 | A3920 | 16d | 0d |  |
|  | 4 | **MOBILIARIOS, BARANDAS Y ESCALERAS** |  | 2023-09-23 | 2023-10-30 |  |  |  |  |
| A3940 |  | ESCALERA DE CONCRETO SOBRE ENROCADO, CIMENTACION Y ANCLAJE | 10d | 2023-09-23 | 2023-10-02 | A3930 | 16d | 0d |  |
| A3950 |  | BARANDA DE MADERA EUCALIPTO CON SOGA, INCLUYE CIMENTACIÓN | 4d | 2023-10-03 | 2023-10-06 | A3940 | 16d | 0d |  |
| A3960 |  | TACHOS DE BASURA, INCLUYE CIMENTACIÓN | 3d | 2023-10-07 | 2023-10-09 | A3950 | 16d | 0d |  |
| A3970 |  | BANCAS DE CONCRETO, INCLUYE CIMENTACIÓN | 10d | 2023-10-10 | 2023-10-19 | A3960 | 16d | 0d |  |
| A3980 |  | POSTES DE ILUMINACIÓN, INCLUYE LUMINARIA Y CIMENTACIÓN | 5d | 2023-10-20 | 2023-10-24 | A3970 | 16d | 0d |  |
| A3990 |  | SEÑALETICA INFORMATIVA | 3d | 2023-10-25 | 2023-10-27 | A3980 | 16d | 0d |  |
| A4000 |  | BOLARDOS DE PIEDRA | 3d | 2023-10-28 | 2023-10-30 | A3990 | 16d | 0d |  |
|  | 5 | **INSTALACIÓN DE ALCORQUES** |  | 2023-10-31 | 2023-11-01 |  |  |  |  |
| A4010 |  | ALCORQUES DE PIEDRA DE CANTO RODADO PARA ARBOLES | 2d | 2023-10-31 | 2023-11-01 | A4000 | 16d | 0d |  |
|  | 4 | **PROGRAMA DE CIERRE DE OBRA** |  | 2023-06-02 | 2023-11-16 |  |  |  |  |
| A1770 |  | ACONDICIONAMIENTO DE DEPOSITOS DE MATERIALES EXCEDENTES (DME) | 160d | 2023-06-02 | 2023-11-08 | A1220 SS | 3d | 0d | Excavación |
| A1780 |  | RESTAURACIÓN DE ÁREAS DE INSTALACIONES PROVISIONALES | 8d | 2023-11-09 | 2023-11-16 | A2480, A1770 | 3d |  |  |
